# MG Brdige[Relationship]

Schedule from Primavera P6, 2011-01-02 to 2013-01-25, data date 2011-01-02.

## Calendars

- MG-Cal3-5D: Mon-Sat 08:00-16:00; Sun off. Exceptions (off unless hours are given): 2011-01-03 to 2011-01-08, 2011-01-10 to 2011-01-15, 2011-01-17 to 2011-01-22, 2011-01-24 to 2011-01-29, 2011-01-31 to 2011-02-05, 2011-02-07, 2011-03-16, 2011-07-18 to 2011-07-22, 2011-08-18 to 2011-08-20, 2011-08-25 to 2011-08-26, 2011-09-12 to 2011-09-13, 2011-12-28 to 2011-12-30, 2012-10-03 07:00-18:00.
- MG-Cal1-7D: Mon-Sun 08:00-16:00.
- MG-Cal2-6D: Mon-Sat 08:00-16:00; Sun off. Exceptions (off unless hours are given): 2011-02-02 to 2011-02-04, 2011-09-12 to 2011-09-14, 2011-11-25, 2012-10-03 07:00-18:00.

## Schedule

| ID | WBS | Activity | Type | Duration | Start | Finish | Predecessors | Total float | Free float | Calendar |
| --- | --- | --- | --- | --- | --- | --- | --- | --- | --- | --- |
|  | M | **주요일정** |  |  | 2011-01-02 | 2011-01-21 |  |  |  |  |
| MM010 |  | 프로젝트 시작 | milestone | 0d | 2011-01-02 | 2011-01-02 |  | 17d | 0d | MG-Cal1-7D |
| MM030 |  | 토공사 완료 | milestone | 0d | 2011-01-02 | 2011-01-02 |  | 754.62d |  | MG-Cal1-7D |
| MM040 |  | 기초공사완료 | milestone | 0d | 2011-01-02 | 2011-01-02 |  | 754.62d |  | MG-Cal1-7D |
| MM050 |  | 구조물공사완료 | milestone | 0d | 2011-01-02 | 2011-01-02 |  | 754.62d |  | MG-Cal1-7D |
| MM060 |  | 방수공사완료 | milestone | 0d | 2011-01-02 | 2011-01-02 |  | 754.62d |  | MG-Cal1-7D |
| MM070 |  | 포장공사완료 | milestone | 0d | 2011-01-02 | 2011-01-02 |  | 754.62d |  | MG-Cal1-7D |
| MM080 |  | 마무리공사 완료 | milestone | 0d | 2011-01-02 | 2011-01-02 |  | 754.62d |  | MG-Cal1-7D |
| MM020 |  | 프로젝트 종료 | milestone | 0d | 2011-01-21 | 2011-01-21 | MCI010, MCI020, MCI030 | 734.62d |  | MG-Cal1-7D |
|  | S | **제출물** |  |  | 2011-01-03 | 2013-01-25 |  |  |  |  |
| MS010 |  | 안전환경서류 |  | 20d | 2011-01-03 | 2011-01-25 |  | 8d |  | MG-Cal2-6D |
| MS020 |  | 착공서류 |  | 20d | 2011-01-03 | 2011-01-25 |  | 8d |  | MG-Cal2-6D |
| MS030 |  | 도로점용서류 |  | 20d | 2011-01-03 | 2011-01-25 |  | 8d |  | MG-Cal2-6D |
| MS040 |  | 자재승인서류 |  | 20d | 2011-01-03 | 2011-01-25 |  | 620d |  | MG-Cal2-6D |
| MS060 |  | 사전준공서류 |  | 20d | 2011-01-03 | 2011-01-25 |  | 620d |  | MG-Cal2-6D |
| MS070 |  | 준공서류 |  | 20d | 2011-01-03 | 2011-01-25 |  | 620d |  | MG-Cal2-6D |
| MS050 |  | 준공도면 |  | 20d | 2013-01-02 | 2013-01-25 | MCW020, MCW030, MCW040, MCW050 | 0d |  | MG-Cal2-6D |
|  | G | **일반사항** |  |  | 2011-01-02 | 2011-03-02 |  |  |  |  |
| MG030 |  | 협력업체선정 |  | 20d | 2011-01-02 | 2011-01-21 | MM010 | 17d | 0d | MG-Cal1-7D |
| MG040 |  | 강재및자재운반 |  | 20d | 2011-01-22 | 2011-02-10 | MG030 | 45d |  | MG-Cal1-7D |
| MG010 |  | 진입도로공사 |  | 20d | 2011-02-08 | 2011-03-02 | MS010, MS020, MS030 | 0d |  |  |
| MG020 |  | 가설사무실설치 |  | 20d | 2011-02-08 | 2011-03-02 | MM010, MG030 | 0d |  |  |
|  | C | **시공** |  |  | 2011-01-02 | 2013-01-02 |  |  |  |  |
|  | I | **간접비** |  |  | 2011-01-02 | 2011-01-21 |  |  |  |  |
| MCI010 |  | 간접비 |  | 20d | 2011-01-02 | 2011-01-21 | MM010 | 734.62d | 0d | MG-Cal1-7D |
| MCI020 |  | 물가인상분 |  | 20d | 2011-01-02 | 2011-01-21 | MM010 | 734.62d | 0d | MG-Cal1-7D |
| MCI030 |  | 품질시험비 |  | 20d | 2011-01-02 | 2011-01-21 | MM010 | 734.62d | 0d | MG-Cal1-7D |

| ID | WBS | Activity | Duration | Start | Finish | Predecessors | Total float | Free float |
| --- | --- | --- | --- | --- | --- | --- | --- | --- |
|  | E | **토공사** |  | 2011-03-03 | 2012-01-18 |  |  |  |
| MCE010 |  | 구조물터파기 | 20d | 2011-03-03 | 2011-03-26 | MG010, MG020 | 0d |  |
| MCE020 |  | 되메우기및다짐 | 20d | 2011-11-07 | 2011-11-29 | MCF090 | 40d | 0d |
| MCE030 |  | 구조물뒷채움 | 20d | 2011-11-30 | 2011-12-22 | MCE020 | 40d | 0d |
| MCE040 |  | 앞성토 | 20d | 2011-12-23 | 2012-01-18 | MCE030 | 40d |  |
|  | F | **기초공사** |  | 2011-03-28 | 2011-11-05 |  |  |  |
| MCF010 |  | RCD굴착(토사,풍화암) | 20d | 2011-03-28 | 2011-04-19 | MG040, MCE010 | 0d |  |
| MCF110 |  | 강관파일공사(S.D.A) | 20d | 2011-03-28 | 2011-04-19 | MCE010 | 120d |  |
| MCF020 |  | RCD굴착(연암) | 20d | 2011-04-20 | 2011-05-12 | MCF010 | 0d |  |
| MCF100 |  | 장비운반 및 조립해체 | 20d | 2011-04-20 | 2011-05-12 | MCF010 | 120d |  |
| MCF030 |  | SLIME제거 | 20d | 2011-05-13 | 2011-06-04 | MCF020 | 0d |  |
| MCF040 |  | 말뚝조성공 | 20d | 2011-06-06 | 2011-06-28 | MCF010, MCF020, MCF030 | 0d |  |
| MCF050 |  | SPACER제작 및 설치 | 20d | 2011-06-29 | 2011-07-27 | MCF040 | 0d |  |
| MCF060 |  | 철근오름방지 | 20d | 2011-07-28 | 2011-08-23 | MCF050 | 0d |  |
| MCF070 |  | 말뚝두부정리 | 20d | 2011-08-24 | 2011-09-20 | MCF060 | 0d |  |
| MCF080 |  | 철근가공조립 | 20d | 2011-09-21 | 2011-10-13 | MCF050, MCF060, MCF070, MCF110 | 0d |  |
| MCF090 |  | 콘크리트 붐 타설(펌프카) | 20d | 2011-10-14 | 2011-11-05 | MCF080, MCF100 | 0d |  |
|  | S | **구조물공사** |  | 2011-11-07 | 2012-06-29 |  |  |  |
| MCS010 |  | 교량기둥 거푸집설치 | 20d | 2011-11-07 | 2011-11-29 | MCF090 | 0d |  |
| MCS020 |  | 교량기둥 비계설치 | 20d | 2011-11-30 | 2011-12-22 | MCS010 | 0d |  |
| MCS030 |  | 교량기둥 동바리설치 | 20d | 2011-12-23 | 2012-01-18 | MCS020 | 0d |  |
| MCS040 |  | 교량기둥 철근가공 및 조립 | 20d | 2011-12-23 | 2012-01-18 | MCS020 | 0d |  |
| MCS050 |  | 교량기둥 콘크리트 타설 | 20d | 2012-01-19 | 2012-02-10 | MCS010, MCS020, MCS030, MCS040 | 0d |  |
| MCS060 |  | 교량슬라브 표면처리 | 20d | 2012-02-11 | 2012-03-05 | MCS050 | 0d |  |
| MCS070 |  | 교량받침설치하기 (A-TYPE) | 20d | 2012-03-06 | 2012-03-28 | MCE040, MCS060 | 0d |  |
| MCS080 |  | 교량받침설치하기 (B-TYPE) | 20d | 2012-03-29 | 2012-04-20 | MCS070 | 0d |  |
| MCS090 |  | 신축이음장치설치 | 20d | 2012-04-21 | 2012-05-14 | MCS080 | 0d |  |
| MCS120 |  | 아치형 행어케이블 설치 | 20d | 2012-04-21 | 2012-05-14 | MCS080 | 40d | 0d |
| MCS100 |  | 접속슬래브 디웰바설치 | 20d | 2012-05-15 | 2012-06-06 | MCS090 | 0d |  |
| MCS110 |  | 교대보호 블럭설치 | 20d | 2012-06-07 | 2012-06-29 | MCS100 | 0d |  |

| ID | WBS | Activity | Duration | Start | Finish | Predecessors | Total float | Calendar |
| --- | --- | --- | --- | --- | --- | --- | --- | --- |
|  | D | **방수공사** |  | 2012-06-30 | 2012-08-15 |  |  |  |
| MCD010 |  | 침투성 교면방수 | 20d | 2012-06-30 | 2012-07-23 | MCS100, MCS110, MCS120 | 0d |  |
| MCD020 |  | 아스팔트 방수 | 20d | 2012-07-24 | 2012-08-15 | MCD010 | 0d |  |
|  | P | **포장공사** |  | 2012-08-16 | 2012-11-16 |  |  |  |
| MCP010 |  | 연결배수고 설치 | 20d | 2012-08-16 | 2012-09-07 | MCD020 | 0d |  |
| MCP020 |  | 배수파이프설치 | 20d | 2012-08-16 | 2012-09-07 | MCD020 | 0d |  |
| MCP030 |  | 택코팅 | 20d | 2012-09-08 | 2012-10-01 | MCD020, MCP010, MCP020 | 0d |  |
| MCP040 |  | 중간층 아스콘포설 및 다짐 | 20d | 2012-10-02 | 2012-10-24 | MCP030 | 0d |  |
| MCP050 |  | 교면표장 | 20d | 2012-10-24 | 2012-11-16 | MCP040 | 0d |  |
|  | W | **마무리공사** |  | 2012-11-16 | 2013-01-02 |  |  |  |
| MCW010 |  | COVER PLATE 설치 | 20d | 2012-11-16 | 2012-12-10 | MCP050 | 0d |  |
| MCW030 |  | 아치형행어케이블설치 | 20d | 2012-11-16 | 2012-12-10 | MCP050 | 20d |  |
| MCW040 |  | McG 그라우팅 | 20d | 2012-11-16 | 2012-12-10 | MCP050 | 20d |  |
| MCW050 |  | 교량유지관리용 표지 설치 | 20d | 2012-11-16 | 2012-12-10 | MCP050 | 20d |  |
| MCW020 |  | 방음벽(교량용) | 20d | 2012-12-10 | 2013-01-02 | MCW010 | 0d |  |
|  | A | **ARCH제작 (외부)** |  | 2011-01-02 | 2012-06-03 |  |  |  |
| MA010 |  | ARCH 주문 및 착수 | 20d | 2011-01-02 | 2011-01-21 |  | 734.62d | MG-Cal1-7D |
| MA020 |  | ARCH 제작 30% | 20d | 2011-01-02 | 2011-01-21 |  | 734.62d | MG-Cal1-7D |
| MA030 |  | ARCH 운반 및 설치 | 20d | 2012-05-15 | 2012-06-03 | MCS120 | 235.62d | MG-Cal1-7D |
