# MG Brdige[Logic Complete]

Schedule from Primavera P6, 2011-01-02 to 2012-10-01, data date 2011-01-02.
Must finish by 2011-12-31

## Calendars

- MG-Cal3-5D: Mon-Sat 08:00-16:00; Sun off. Exceptions (off unless hours are given): 2011-01-03 to 2011-01-08, 2011-01-10 to 2011-01-15, 2011-01-17 to 2011-01-22, 2011-01-24 to 2011-01-29, 2011-01-31 to 2011-02-05, 2011-02-07, 2011-03-16, 2011-07-18 to 2011-07-22, 2011-08-18 to 2011-08-20, 2011-08-25 to 2011-08-26, 2011-09-12 to 2011-09-13, 2011-12-28 to 2011-12-30.
- MG-Cal1-7D: Mon-Sun 08:00-16:00.
- MG-Cal2-6D: Mon-Sat 08:00-16:00; Sun off. Exceptions (off unless hours are given): 2011-02-02 to 2011-02-04, 2011-09-12 to 2011-09-14, 2011-11-25.

## Schedule

| ID | WBS | Activity | Type | Duration | Start | Finish | Predecessors | Total float | Free float | Calendar |
| --- | --- | --- | --- | --- | --- | --- | --- | --- | --- | --- |
|  | M | **주요일정** |  |  | 2011-01-02 | 2012-10-01 |  |  |  |  |
| MM010 |  | 프로젝트 시작 | milestone | 0d | 2011-01-02 | 2011-01-02 |  | -295d | 0d | MG-Cal1-7D |
| MM040 |  | 기초공사완료 | milestone | 0d | 2011-08-23 | 2011-08-23 | MCF090 | 130d | 405d | MG-Cal1-7D |
| MM030 |  | 토공사 완료 | milestone | 0d | 2011-11-05 | 2011-11-05 | MCE040 | 56d | 331d | MG-Cal1-7D |
| MM050 |  | 구조물공사완료 | milestone | 0d | 2012-03-05 | 2012-03-05 | MCS110 | -65d | 210d | MG-Cal1-7D |
| MM060 |  | 방수공사완료 | milestone | 0d | 2012-04-20 | 2012-04-20 | MCD020 | -111d | 164d | MG-Cal1-7D |
| MM070 |  | 포장공사완료 | milestone | 0d | 2012-07-23 | 2012-07-23 | MCP050 | -205d | 70d | MG-Cal1-7D |
| MM080 |  | 마무리공사 완료 | milestone | 0d | 2012-09-07 | 2012-09-07 | MCW020, MCW010, MCW030, MCW040, MCW050 | -251d | 24d | MG-Cal1-7D |
| MM020 |  | 프로젝트 종료 | milestone | 0d | 2012-10-01 | 2012-10-01 | MCI010, MCI020, MCI030, MS070, MS050, MS040 | -275d | 0d | MG-Cal1-7D |
|  | S | **제출물** |  |  | 2011-01-03 | 2012-10-01 |  |  |  |  |
| MS010 |  | 안전환경서류 |  | 20d | 2011-01-03 | 2011-01-25 | MM010 | -252d | 8d | MG-Cal2-6D |
| MS020 |  | 착공서류 |  | 20d | 2011-01-03 | 2011-01-25 | MM010 | -252d | 8d | MG-Cal2-6D |
| MS030 |  | 도로점용서류 |  | 20d | 2011-01-03 | 2011-01-25 | MM010 | -252d | 8d | MG-Cal2-6D |
| MS040 |  | 자재승인서류 |  | 20d | 2011-01-03 | 2011-01-25 | MM010 | 220d | 11d | MG-Cal2-6D |
| MS060 |  | 사전준공서류 |  | 20d | 2012-02-08 | 2012-03-01 | MA030 | -72d | 0d | MG-Cal2-6D |
| MS070 |  | 준공서류 |  | 20d | 2012-03-02 | 2012-03-24 | MS060 | -72d | 163d | MG-Cal2-6D |
| MS050 |  | 준공도면 |  | 20d | 2012-09-08 | 2012-10-01 | MCW020, MCW030, MCW040, MCW050 | -235d | 0d | MG-Cal2-6D |
|  | G | **일반사항** |  |  | 2011-01-02 | 2011-03-02 |  |  |  |  |
| MG030 |  | 협력업체선정 |  | 20d | 2011-01-02 | 2011-01-21 | MM010 | -291d | 0d | MG-Cal1-7D |
| MG040 |  | 강재및자재운반 |  | 20d | 2011-01-22 | 2011-02-10 | MG030 | -265d | 45d | MG-Cal1-7D |
| MG010 |  | 진입도로공사 |  | 20d | 2011-02-08 | 2011-03-02 | MS010, MS020, MS030 | -232d | 0d |  |
| MG020 |  | 가설사무실설치 |  | 20d | 2011-02-08 | 2011-03-02 | MM010, MG030 | -232d | 0d |  |
|  | C | **시공** |  |  | 2011-01-02 | 2012-09-07 |  |  |  |  |
|  | I | **간접비** |  |  | 2011-01-02 | 2011-12-31 |  |  |  |  |
| MCI010 |  | 간접비 |  | 364d | 2011-01-02 | 2011-12-31 | MM010 | 0d | 275d | MG-Cal1-7D |
| MCI020 |  | 물가인상분 |  | 364d | 2011-01-02 | 2011-12-31 | MM010 | 0d | 275d | MG-Cal1-7D |
| MCI030 |  | 품질시험비 |  | 364d | 2011-01-02 | 2011-12-31 | MM010 | 0d | 275d | MG-Cal1-7D |

| ID | WBS | Activity | Duration | Start | Finish | Predecessors | Total float | Free float |
| --- | --- | --- | --- | --- | --- | --- | --- | --- |
|  | E | **토공사** |  | 2011-03-03 | 2011-11-05 |  |  |  |
| MCE010 |  | 구조물터파기 | 20d | 2011-03-03 | 2011-03-26 | MG010, MG020 | -232d | 0d |
| MCE020 |  | 되메우기및다짐 | 20d | 2011-08-24 | 2011-09-20 | MCF090 | -212d | 0d |
| MCE030 |  | 구조물뒷채움 | 20d | 2011-09-21 | 2011-10-13 | MCE020 | -212d | 0d |
| MCE040 |  | 앞성토 | 20d | 2011-10-14 | 2011-11-05 | MCE030 | -212d | 0d |
|  | F | **기초공사** |  | 2011-03-28 | 2011-08-23 |  |  |  |
| MCF010 |  | RCD굴착(토사,풍화암) | 20d | 2011-03-28 | 2011-04-19 | MG040, MCE010 | -232d | 0d |
| MCF020 |  | RCD굴착(연암) | 20d | 2011-03-28 | 2011-04-19 | MCF010 SS | -232d | 0d |
| MCF030 |  | SLIME제거 | 20d | 2011-03-28 | 2011-04-19 | MCF020 SS | -232d | 0d |
| MCF110 |  | 강관파일공사(S.D.A) | 20d | 2011-03-28 | 2011-04-19 | MCE010 | -172d | 60d |
| MCF040 |  | 말뚝조성공 | 20d | 2011-04-20 | 2011-05-12 | MCF010, MCF020, MCF030 | -232d | 0d |
| MCF100 |  | 장비운반 및 조립해체 | 20d | 2011-04-20 | 2011-05-12 | MCF010 | -172d | 60d |
| MCF050 |  | SPACER제작 및 설치 | 20d | 2011-05-13 | 2011-06-04 | MCF040 | -232d | 0d |
| MCF060 |  | 철근오름방지 | 20d | 2011-05-13 | 2011-06-04 | MCF050 SS | -232d | 0d |
| MCF070 |  | 말뚝두부정리 | 20d | 2011-06-06 | 2011-06-28 | MCF060 | -232d | 0d |
| MCF080 |  | 철근가공조립 | 20d | 2011-06-29 | 2011-07-27 | MCF050, MCF060, MCF070, MCF110 | -232d | 0d |
| MCF090 |  | 콘크리트 붐 타설(펌프카) | 20d | 2011-07-28 | 2011-08-23 | MCF080, MCF100 | -232d | 0d |
|  | S | **구조물공사** |  | 2011-08-24 | 2012-03-05 |  |  |  |
| MCS010 |  | 교량기둥 거푸집설치 | 20d | 2011-08-24 | 2011-09-20 | MCF090 | -232d | 0d |
| MCS020 |  | 교량기둥 비계설치 | 20d | 2011-08-24 | 2011-09-20 | MCS010 SS | -232d | 0d |
| MCS030 |  | 교량기둥 동바리설치 | 20d | 2011-08-24 | 2011-09-20 | MCS020 SS | -212d | 20d |
| MCS040 |  | 교량기둥 철근가공 및 조립 | 20d | 2011-09-21 | 2011-10-13 | MCS020 | -232d | 0d |
| MCS050 |  | 교량기둥 콘크리트 타설 | 20d | 2011-10-14 | 2011-11-05 | MCS010, MCS020, MCS030, MCS040 | -232d | 0d |
| MCS060 |  | 교량슬라브 표면처리 | 20d | 2011-11-07 | 2011-11-29 | MCS050 | -232d | 0d |
| MCS070 |  | 교량받침설치하기 (A-TYPE) | 20d | 2011-11-30 | 2011-12-22 | MCE040, MCS060 | -232d | 0d |
| MCS080 |  | 교량받침설치하기 (B-TYPE) | 20d | 2011-11-30 | 2011-12-22 | MCS070 SS | -232d | 0d |
| MCS090 |  | 신축이음장치설치 | 20d | 2011-12-23 | 2012-01-18 | MCS080 | -232d | 0d |
| MCS120 |  | 아치형 행어케이블 설치 | 20d | 2011-12-23 | 2012-01-18 | MCS080 | -192d | 0d |
| MCS100 |  | 접속슬래브 디웰바설치 | 20d | 2012-01-19 | 2012-02-10 | MCS090 | -232d | 0d |
| MCS110 |  | 교대보호 블럭설치 | 20d | 2012-02-11 | 2012-03-05 | MCS100 | -232d | 0d |

| ID | WBS | Activity | Duration | Start | Finish | Predecessors | Total float | Free float | Calendar |
| --- | --- | --- | --- | --- | --- | --- | --- | --- | --- |
|  | D | **방수공사** |  | 2012-03-06 | 2012-04-20 |  |  |  |  |
| MCD010 |  | 침투성 교면방수 | 20d | 2012-03-06 | 2012-03-28 | MCS100, MCS110, MCS120 | -232d | 0d |  |
| MCD020 |  | 아스팔트 방수 | 20d | 2012-03-29 | 2012-04-20 | MCD010 | -232d | 0d |  |
|  | P | **포장공사** |  | 2012-04-21 | 2012-07-23 |  |  |  |  |
| MCP010 |  | 연결배수고 설치 | 20d | 2012-04-21 | 2012-05-14 | MCD020 | -232d | 0d |  |
| MCP020 |  | 배수파이프설치 | 20d | 2012-04-21 | 2012-05-14 | MCD020 | -232d | 0d |  |
| MCP030 |  | 택코팅 | 20d | 2012-05-15 | 2012-06-06 | MCD020, MCP010, MCP020 | -232d | 0d |  |
| MCP040 |  | 중간층 아스콘포설 및 다짐 | 20d | 2012-06-07 | 2012-06-29 | MCP030 | -232d | 0d |  |
| MCP050 |  | 교면표장 | 20d | 2012-06-30 | 2012-07-23 | MCP040 | -232d | 0d |  |
|  | W | **마무리공사** |  | 2012-07-24 | 2012-09-07 |  |  |  |  |
| MCW010 |  | COVER PLATE 설치 | 20d | 2012-07-24 | 2012-08-15 | MCP050 | -232d | 0d |  |
| MCW030 |  | 아치형행어케이블설치 | 20d | 2012-07-24 | 2012-08-15 | MCP050 | -212d | 20d |  |
| MCW040 |  | McG 그라우팅 | 20d | 2012-07-24 | 2012-08-15 | MCP050 | -212d | 20d |  |
| MCW050 |  | 교량유지관리용 표지 설치 | 20d | 2012-07-24 | 2012-08-15 | MCP050 | -212d | 20d |  |
| MCW020 |  | 방음벽(교량용) | 20d | 2012-08-16 | 2012-09-07 | MCW010 | -232d | 0d |  |
|  | A | **ARCH제작 (외부)** |  | 2011-01-22 | 2012-02-07 |  |  |  |  |
| MA010 |  | ARCH 주문 및 착수 | 20d | 2011-01-22 | 2011-02-10 | MM010, MG030 | 247d | 0d | MG-Cal1-7D |
| MA020 |  | ARCH 제작 30% | 10d | 2011-02-11 | 2011-02-20 | MA010, MS040 | 247d | 332d | MG-Cal1-7D |
| MA030 |  | ARCH 운반 및 설치 | 20d | 2012-01-19 | 2012-02-07 | MCS120, MA020 | -85d | 0d | MG-Cal1-7D |
