# MG Brdige[Complete)

Schedule from Primavera P6, 2011-01-02 to 2011-12-31, data date 2011-01-02, costs in KRW.
Must finish by 2011-12-31

## Calendars

- MG-Cal3-5D: Mon-Sat 08:00-16:00; Sun off. Exceptions (off unless hours are given): 2011-01-03 to 2011-01-08, 2011-01-10 to 2011-01-15, 2011-01-17 to 2011-01-22, 2011-01-24 to 2011-01-29, 2011-01-31 to 2011-02-05, 2011-02-07, 2011-03-16, 2011-07-18 to 2011-07-22, 2011-08-18 to 2011-08-20, 2011-08-25 to 2011-08-26, 2011-09-12 to 2011-09-13, 2011-12-28 to 2011-12-30.
- MG-Cal1-7D: Mon-Sun 08:00-16:00.
- MG-Cal2-6D: Mon-Sat 08:00-16:00; Sun off. Exceptions (off unless hours are given): 2011-02-02 to 2011-02-04, 2011-09-12 to 2011-09-14, 2011-11-25.

## Resources

| Resource | Group | Rate |
| --- | --- | --- |
| 형강운반비 | labor | 3125 |
| 포대시멘트운반 | labor | 250 |
| 철근운반 | labor | 2500 |
| 간접 | labor | 0.12 |
| 파일재하시험비 | labor | 2081250 |
| 특별인부 | labor |  |
| 백호 1.0 | equipment |  |
| 구조물터파기 | labor | 643.75 |
| 보통인부 | labor |  |
| 트럭24ton | equipment |  |
| 진동로라 0.7 | equipment |  |
| 도쟈32ton | equipment |  |
| 되메우기및다짐 | labor | 584.12 |
| 구조물뒷채움 | labor | 1062.5 |
| 앞성토 | labor | 750 |
| 인부(RCD) | labor |  |
| RCD 장비 | equipment |  |
| RCD | material |  |
| RCD굴착(토사,풍화암) | labor | 538750 |
| RCD굴착(연암) | labor | 232000 |
| SLIME제거 | labor | 20250 |
| 말뚝조성공 | labor | 279875 |
| CASING손료 | labor | 349250 |
| SPACER제작및설치 | labor | 12750 |
| 철근오름방지 | labor | 53000 |
| 말뚝두부정리 | labor | 20375 |
| 철근공 | labor |  |
| 철근 | material |  |
| 철근가공조립 | labor | 12750 |
| 콘크리트붐타설(펌프카) | labor | 375 |
| 무한궤도 크레인 150ton | equipment |  |
| 장비운반및조립해체 | labor | 507625 |
| 자재비(R=508M/M,T=12M/M) | labor | 11125 |
| 콘크리트붐타설(펌프카) | labor | 500 |
| 강관천공후항타비 | labor | 3375 |
| 강관파일두부보강(볼트식) | labor | 10750 |
| 거푸집 (0-7M) | labor | 2875 |
| 거푸집 (10-13M) | labor | 3375 |
| 거푸집 (13-16M) | labor | 3625 |
| 강관비계 | labor | 1625 |
| 강관동바리 | labor | 3000 |
| 목재동바리 | labor | 3500 |
| 목재동바리 (4회) | labor | 3500 |
| 수평연결재 | labor | 500 |
| 철근가공조립 (간단) | labor | 11250 |
| 철근가공조립 (보통) | labor | 12875 |
| 철근가공조립 (복잡) | labor | 14125 |
| 콘크리트 | material |  |
| 콘크리트타설(철근) | labor | 625 |
| 슬래브양생 | labor | 375 |
| 슬래브면고르기 | labor | 375 |
| 교량받침 | material |  |
| 교량받침 (A-Type) | labor | 1885500 |
| 교량받침 (B-Type) | labor | 2228875 |
| 신축이음장치(FINRER) 160mm | labor | 281500 |
| 신축이음장치(FINRER) 200mm | labor | 345250 |
| 다웰바설치(접속슬래브) | labor | 1750 |
| 교대보호블럭 | labor | 1500 |
| 용접공 | labor |  |
| 케이블 | material |  |
| 방수공 | labor |  |
| 교면방수(침투성) | labor | 2375 |
| 아스팔트방수 | labor | 875 |
| 배관공 | labor |  |
| 연결배수구(T형) | labor | 16375 |
| 연결배수구(L형) | labor | 2625 |
| 배수PIPE | labor | 125 |
| 택코팅 | labor | 1875 |
| 아스팔트 | material |  |
| 중간층아스콘포설및다짐 | labor | 6125 |
| 교면포장 | labor | 6125 |
| 방음벽용 | labor | 38125 |
| 중분대용 | labor | 48250 |
| 방음벽(교량용) | labor | 19375 |
| 아치형행어케이블설치 | labor | 18750000 |
| 토사천공 | labor | 2443.75 |
| 그라우팅주입비 | labor | 12739 |
| 주입재료비 | labor | 17598.8 |
| 교량유지관리용표지 (교각용) | labor | 4500 |
| ARCH | material |  |
| Arch 제작 | labor | 0.12 |

## Schedule

| ID | WBS | Activity | Type | Duration | Start | Finish | Predecessors | Total float | Free float | Calendar | Resources | Cost |
| --- | --- | --- | --- | --- | --- | --- | --- | --- | --- | --- | --- | --- |
|  | M | **주요일정** |  |  | 2011-01-02 | 2011-12-31 |  |  |  |  |  |  |
| MM010 |  | 프로젝트 시작 | milestone | 0d | 2011-01-02 | 2011-01-02 |  | 0d |  | MG-Cal1-7D |  |  |
| MM040 |  | 기초공사완료 | milestone | 0d | 2011-06-22 | 2011-06-22 | MCF090 | 192d |  | MG-Cal1-7D |  |  |
| MM030 |  | 토공사 완료 | milestone | 0d | 2011-07-11 | 2011-07-11 | MCE040 | 173d |  | MG-Cal1-7D |  |  |
| MM050 |  | 구조물공사완료 | milestone | 0d | 2011-10-12 | 2011-10-12 | MCS110 | 80d |  | MG-Cal1-7D |  |  |
| MM060 |  | 방수공사완료 | milestone | 0d | 2011-10-29 | 2011-10-29 | MCD020 | 63d |  | MG-Cal1-7D |  |  |
| MM070 |  | 포장공사완료 | milestone | 0d | 2011-12-06 | 2011-12-06 | MCP050 | 25d |  | MG-Cal1-7D |  |  |
| MM080 |  | 마무리공사 완료 | milestone | 0d | 2011-12-26 | 2011-12-26 | MCW020, MCW010, MCW030, MCW040, MCW050 | 5d |  | MG-Cal1-7D |  |  |
| MM020 |  | 프로젝트 종료 | milestone | 0d | 2011-12-31 | 2011-12-31 | MCI010, MCI020, MCI030, MS070, MS050, MS040 | 0d |  | MG-Cal1-7D |  |  |
|  | S | **제출물** |  |  | 2011-01-03 | 2011-12-31 |  |  |  |  |  |  |
| MS010 |  | 안전환경서류 |  | 8d | 2011-01-03 | 2011-01-11 | MM010 | 20d |  | MG-Cal2-6D |  |  |
| MS020 |  | 착공서류 |  | 10d | 2011-01-03 | 2011-01-13 | MM010 | 18d |  | MG-Cal2-6D |  |  |
| MS030 |  | 도로점용서류 |  | 10d | 2011-01-03 | 2011-01-13 | MM010 | 18d |  | MG-Cal2-6D |  |  |
| MS040 |  | 자재승인서류 |  | 30d | 2011-01-03 | 2011-02-09 | MM010 | 53d | 0d | MG-Cal2-6D |  |  |
| MS060 |  | 사전준공서류 |  | 10d | 2011-10-08 | 2011-10-19 | MA030 | 52d | 0d | MG-Cal2-6D |  |  |
| MS070 |  | 준공서류 |  | 10d | 2011-10-20 | 2011-10-31 | MS060 | 52d |  | MG-Cal2-6D |  |  |
| MS050 |  | 준공도면 |  | 5d | 2011-12-27 | 2011-12-31 | MCW020, MCW030, MCW040, MCW050 | 0d |  | MG-Cal2-6D |  |  |
|  | G | **일반사항** |  |  | 2011-01-02 | 2011-02-21 |  |  |  |  |  |  |
| MG030 |  | 협력업체선정 |  | 3d | 2011-01-02 | 2011-01-04 | MM010 | 40d | 0d | MG-Cal1-7D |  |  |
| MG040 |  | 강재및자재운반 |  | 7d | 2011-01-05 | 2011-01-11 | MG030 | 56d |  | MG-Cal1-7D | 형강운반비 [1200 h]; 포대시멘트운반 [16000 h]; 철근운반 [20000 h] | 57,750,000 |
| MG010 |  | 진입도로공사 |  | 12d | 2011-02-08 | 2011-02-21 | MS010, MS020, MS030 | 0d |  |  |  |  |
| MG020 |  | 가설사무실설치 |  | 7d | 2011-02-08 | 2011-02-15 | MM010, MG030 | 5d |  |  |  |  |
|  | C | **시공** |  |  | 2011-01-02 | 2011-12-31 |  |  |  |  |  |  |
|  | I | **간접비** |  |  | 2011-01-02 | 2011-12-31 |  |  |  |  |  |  |
| MCI010 |  | 간접비 |  | 364d | 2011-01-02 | 2011-12-31 | MM010 | 0d |  | MG-Cal1-7D | 간접 [16000000000 h] | 2,000,000,000 |
| MCI020 |  | 물가인상분 |  | 364d | 2011-01-02 | 2011-12-31 | MM010 | 0d |  | MG-Cal1-7D |  |  |
| MCI030 |  | 품질시험비 |  | 364d | 2011-01-02 | 2011-12-31 | MM010 | 0d |  | MG-Cal1-7D | 파일재하시험비 [8 h] | 16,650,000 |

| ID | WBS | Activity | Duration | Start | Finish | Predecessors | Total float | Free float | Resources | Cost |
| --- | --- | --- | --- | --- | --- | --- | --- | --- | --- | --- |
|  | E | **토공사** |  | 2011-02-22 | 2011-07-11 |  |  |  |  |  |
| MCE010 |  | 구조물터파기 | 13d | 2011-02-22 | 2011-03-08 | MG010, MG020 | 0d |  | 특별인부 [584 h]; 백호 1.0 [296 h]; 구조물터파기 [176000 h] | 113,300,000 |
| MCE020 |  | 되메우기및다짐 | 7d | 2011-06-23 | 2011-06-30 | MCF090 | 49d | 0d | 보통인부 [104 h]; 특별인부 [104 h]; 백호 1.0 [104 h]; 트럭24ton [104 h]; 진동로라 0.7 [48 h]; 도쟈32ton [56 h]; 되메우기및다짐 [80000 h] | 46,730,000 |
| MCE030 |  | 구조물뒷채움 | 3d | 2011-07-01 | 2011-07-04 | MCE020 | 49d | 0d | 보통인부 [48 h]; 백호 1.0 [24 h]; 트럭24ton [24 h]; 구조물뒷채움 [4608 h] | 4,896,000 |
| MCE040 |  | 앞성토 | 6d | 2011-07-05 | 2011-07-11 | MCE030 | 49d | 0d | 보통인부 [48 h]; 백호 1.0 [24 h]; 트럭24ton [24 h]; 앞성토 [32648 h] | 24,486,000 |
|  | F | **기초공사** |  | 2011-03-09 | 2011-06-22 |  |  |  |  |  |
| MCF010 |  | RCD굴착(토사,풍화암) | 17d | 2011-03-09 | 2011-03-29 | MG040, MCE010 | 0d |  | 인부(RCD) [264 h]; RCD 장비 [136 h]; RCD [17]; RCD굴착(토사,풍화암) [2000 h] | 1,077,500,000 |
| MCF020 |  | RCD굴착(연암) | 17d | 2011-03-09 | 2011-03-29 | MCF010 SS | 0d |  | RCD 장비 [136 h]; 인부(RCD) [264 h]; RCD굴착(연암) [2000 h] | 464,000,000 |
| MCF030 |  | SLIME제거 | 17d | 2011-03-09 | 2011-03-29 | MCF020 SS | 0d |  | 트럭24ton [64 h]; 보통인부 [264 h]; SLIME제거 [2000 h] | 40,500,000 |
| MCF110 |  | 강관파일공사(S.D.A) | 5d | 2011-03-09 | 2011-03-14 | MCE010 | 63d |  | 특별인부 [264 h]; 자재비(R=508M/M,T=12M/M) [8000 h]; 콘크리트붐타설(펌프카) [1600 h]; 강관천공후항타비 [6400 h]; 강관파일두부보강(볼트식) [2000 h] | 132,900,000 |
| MCF040 |  | 말뚝조성공 | 17d | 2011-03-30 | 2011-04-18 | MCF010, MCF020, MCF030 | 0d |  | 특별인부 [264 h]; 말뚝조성공 [2000 h]; CASING손료 [2000 h] | 1,258,250,000 |
| MCF100 |  | 장비운반 및 조립해체 | 10d | 2011-03-30 | 2011-04-09 | MCF010 | 60d |  | 특별인부 [160 h]; 무한궤도 크레인 150ton [80 h]; 장비운반및조립해체 [80 h] | 40,610,000 |
| MCF050 |  | SPACER제작 및 설치 | 17d | 2011-04-19 | 2011-05-07 | MCF040 | 0d |  | 보통인부 [136 h]; SPACER제작및설치 [2000 h] | 25,500,000 |
| MCF060 |  | 철근오름방지 | 17d | 2011-04-19 | 2011-05-07 | MCF050 SS | 0d |  | 특별인부 [264 h]; 철근오름방지 [2000 h] | 106,000,000 |
| MCF070 |  | 말뚝두부정리 | 17d | 2011-05-09 | 2011-05-27 | MCF060 | 0d |  | 특별인부 [264 h]; 말뚝두부정리 [2000 h] | 40,750,000 |
| MCF080 |  | 철근가공조립 | 19d | 2011-05-28 | 2011-06-18 | MCF050, MCF060, MCF070, MCF110 | 0d |  | 철근공 [1200 h]; 철근 [300]; 철근가공조립 [2400 h] | 30,600,000 |
| MCF090 |  | 콘크리트 붐 타설(펌프카) | 3d | 2011-06-20 | 2011-06-22 | MCF080, MCF100 | 0d |  | 특별인부 [1336 h]; 콘크리트붐타설(펌프카) [40000 h] | 15,000,000 |
|  | S | **구조물공사** |  | 2011-06-23 | 2011-10-12 |  |  |  |  |  |
| MCS010 |  | 교량기둥 거푸집설치 | 16d | 2011-06-23 | 2011-07-11 | MCF090 | 0d |  | 특별인부 [1264 h]; 거푸집 (0-7M) [144000 h]; 거푸집 (10-13M) [8000 h]; 거푸집 (13-16M) [12000 h] | 484,500,000 |
| MCS020 |  | 교량기둥 비계설치 | 14d | 2011-06-23 | 2011-07-08 | MCS010 SS | 0d |  | 특별인부 [1120 h]; 보통인부 [1120 h]; 강관비계 [56000 h] | 91,000,000 |
| MCS030 |  | 교량기둥 동바리설치 | 18d | 2011-06-23 | 2011-07-13 | MCS020 SS | 14d |  | 보통인부 [1416 h]; 특별인부 [1416 h]; 강관동바리 [40000 h]; 목재동바리 [24000 h]; 목재동바리 (4회) [72000 h]; 수평연결재 [20000 h] | 466,000,000 |
| MCS040 |  | 교량기둥 철근가공 및 조립 | 18d | 2011-07-09 | 2011-08-04 | MCS020 | 0d |  | 철근공 [2072 h]; 철근 [1551]; 철근가공조립 (간단) [8 h]; 철근가공조립 (보통) [400 h]; 철근가공조립 (복잡) [12000 h] | 174,740,000 |
| MCS050 |  | 교량기둥 콘크리트 타설 | 15d | 2011-08-05 | 2011-08-27 | MCS010, MCS020, MCS030, MCS040 | 0d |  | 특별인부 [1200 h]; 콘크리트 [12000]; 콘크리트타설(철근) [96000 h] | 60,000,000 |
| MCS060 |  | 교량슬라브 표면처리 | 18d | 2011-08-29 | 2011-09-20 | MCS050 | 0d |  | 보통인부 [2184 h]; 슬래브양생 [120000 h]; 슬래브면고르기 [120000 h] | 90,000,000 |
| MCS070 |  | 교량받침설치하기 (A-TYPE) | 8d | 2011-09-21 | 2011-09-29 | MCE040, MCS060 | 0d |  | 특별인부 [120 h]; 교량받침 [8]; 교량받침 (A-Type) [120 h] | 226,260,000 |
| MCS080 |  | 교량받침설치하기 (B-TYPE) | 8d | 2011-09-21 | 2011-09-29 | MCS070 SS | 0d |  | 특별인부 [120 h]; 교량받침 [8]; 교량받침 (B-Type) [120 h] | 267,465,000 |
| MCS090 |  | 신축이음장치설치 | 3d | 2011-09-30 | 2011-10-03 | MCS080 | 0d |  | 보통인부 [48 h]; 신축이음장치(FINRER) 160mm [264 h]; 신축이음장치(FINRER) 200mm [296 h] | 176,510,000 |
| MCS120 |  | 아치형 행어케이블 설치 | 10d | 2011-09-30 | 2011-10-11 | MCS080 | 1d |  | 용접공 [56 h]; 무한궤도 크레인 150ton [160 h]; 케이블 [10] |  |
| MCS100 |  | 접속슬래브 디웰바설치 | 3d | 2011-10-04 | 2011-10-06 | MCS090 | 0d |  | 특별인부 [88 h]; 다웰바설치(접속슬래브) [656 h] | 1,148,000 |
| MCS110 |  | 교대보호 블럭설치 | 5d | 2011-10-07 | 2011-10-12 | MCS100 | 0d |  | 특별인부 [128 h]; 교대보호블럭 [3880 h] | 5,820,000 |

| ID | WBS | Activity | Duration | Start | Finish | Predecessors | Total float | Free float | Calendar | Resources | Cost |
| --- | --- | --- | --- | --- | --- | --- | --- | --- | --- | --- | --- |
|  | D | **방수공사** |  | 2011-10-13 | 2011-10-29 |  |  |  |  |  |  |
| MCD010 |  | 침투성 교면방수 | 9d | 2011-10-13 | 2011-10-22 | MCS100, MCS110, MCS120 | 0d |  |  | 방수공 [264 h]; 교면방수(침투성) [79136 h] | 187,948,000 |
| MCD020 |  | 아스팔트 방수 | 6d | 2011-10-24 | 2011-10-29 | MCD010 | 0d |  |  | 방수공 [136 h]; 아스팔트방수 [1856 h] | 1,624,000 |
|  | P | **포장공사** |  | 2011-10-31 | 2011-12-06 |  |  |  |  |  |  |
| MCP010 |  | 연결배수고 설치 | 10d | 2011-10-31 | 2011-11-10 | MCD020 | 2d |  |  | 배관공 [160 h]; 연결배수구(T형) [400 h]; 연결배수구(L형) [160 h] | 6,970,000 |
| MCP020 |  | 배수파이프설치 | 12d | 2011-10-31 | 2011-11-12 | MCD020 | 0d |  |  | 배관공 [264 h]; 배수PIPE [1600 h] | 200,000 |
| MCP030 |  | 택코팅 | 4d | 2011-11-14 | 2011-11-17 | MCD020, MCP010, MCP020 | 0d |  |  | 특별인부 [248 h]; 택코팅 [2000 h] | 3,750,000 |
| MCP040 |  | 중간층 아스콘포설 및 다짐 | 8d | 2011-11-18 | 2011-11-26 | MCP030 | 0d |  |  | 특별인부 [240 h]; 아스팔트 [120]; 중간층아스콘포설및다짐 [960 h] | 5,880,000 |
| MCP050 |  | 교면표장 | 8d | 2011-11-28 | 2011-12-06 | MCP040 | 0d |  |  | 특별인부 [240 h]; 교면포장 [960 h] | 5,880,000 |
|  | W | **마무리공사** |  | 2011-12-07 | 2011-12-26 |  |  |  |  |  |  |
| MCW010 |  | COVER PLATE 설치 | 4d | 2011-12-07 | 2011-12-10 | MCP050 | 6d | 0d |  | 용접공 [360 h] |  |
| MCW030 |  | 아치형행어케이블설치 | 10d | 2011-12-07 | 2011-12-17 | MCP050 | 7d |  |  | 용접공 [480 h]; 무한궤도 크레인 150ton [320 h]; 아치형행어케이블설치 |  |
| MCW040 |  | McG 그라우팅 | 17d | 2011-12-07 | 2011-12-26 | MCP050 | 0d |  |  | 특별인부 [800 h]; 토사천공 [8000 h]; 그라우팅주입비 [8000 h]; 주입재료비 [800 h] | 135,541,000 |
| MCW050 |  | 교량유지관리용 표지 설치 | 10d | 2011-12-07 | 2011-12-17 | MCP050 | 7d |  |  | 교량유지관리용표지 (교각용) [160 h] | 720,000 |
| MCW020 |  | 방음벽(교량용) | 7d | 2011-12-12 | 2011-12-19 | MCW010 | 6d |  |  | 특별인부 [320 h]; 방음벽용 [16 h]; 중분대용 [16 h]; 방음벽(교량용) [6400 h] | 125,382,000 |
|  | A | **ARCH제작 (외부)** |  | 2011-01-05 | 2011-10-07 |  |  |  |  |  |  |
| MA010 |  | ARCH 주문 및 착수 | 30d | 2011-01-05 | 2011-02-03 | MM010, MG030 | 68d | 6d | MG-Cal1-7D | ARCH [30]; Arch 제작 [21569376000 h] | 2,696,172,000 |
| MA020 |  | ARCH 제작 30% | 150d | 2011-02-10 | 2011-07-09 | MA010, MS040 | 62d | 0d | MG-Cal1-7D | ARCH [150]; Arch 제작 [21569376000 h] | 2,696,172,000 |
| MA030 |  | ARCH 운반 및 설치 | 90d | 2011-07-10 | 2011-10-07 | MA020 | 62d | 0d | MG-Cal1-7D | ARCH [90]; Arch 제작 [28759168000 h] | 3,594,896,000 |
